Schedule from Planner, 2014-09-01 to 2017-05-31.

## Calendars

- Default: Mon-Fri 08:00-12:00, 13:00-17:00; Sat-Sun off.

## Schedule

| ID | Task | Type | Duration | Start | Finish | Predecessors | Complete | Constraint | Work |
| --- | --- | --- | --- | --- | --- | --- | --- | --- | --- |
| 1 | Supercam Instrument Validation |  |  | 2014-09-01 | 2014-10-24 |  |  |  | 320h |
| 2 | Supercam Instrument Readiness Review | milestone | 0d | 2014-10-24 | 2014-10-24 | 1 |  |  |  |
| 3 | First Supercam Observing Run at HHT |  |  | 2014-11-03 | 2014-12-05 |  |  | must start on 2014-11-01 | 200h |
| 4 | First run data processing |  |  | 2014-12-08 | 2015-02-27 | 3 |  |  | 480h |
| 5 | Second Supercam Observing Run at HHT |  |  | 2015-03-02 | 2015-04-03 |  |  | must start on 2015-03-01 | 200h |
| 6 | Second run data processing |  |  | 2015-04-06 | 2015-09-03 | 5 |  |  | 866.75h |
| 7 | Data Release 1 | milestone | 0d | 2015-09-03 | 2015-09-03 | 6 |  |  |  |
| 8 | Third Supercam Observing Run at HHT |  |  | 2015-11-02 | 2015-12-04 |  |  | must start on 2015-11-01 | 200h |
| 9 | Third run data processing |  |  | 2015-12-07 | 2016-02-26 | 8 |  |  | 480h |
| 10 | Fourth Supercam Observing Run at HHT |  |  | 2016-03-01 | 2016-04-04 |  |  | must start on 2016-03-01 | 200h |
| 11 | Fourth run data processing |  |  | 2016-04-05 | 2016-09-20 | 10 |  |  | 968h |
| 12 | Data Release 2 | milestone | 0d | 2016-09-20 | 2016-09-20 | 11 |  |  |  |
| 13 | Follow-up HCO+ Supercam observations at HHT |  |  | 2016-11-01 | 2016-11-11 |  | 9% | must start on 2016-11-01 | 69.5h |
| 14 | Final survey and ancillary data processing |  |  | 2016-11-11 | 2017-05-31 | 13 |  |  | 1140.5h |
| 15 | Final Data Release 3 | milestone | 0d | 2017-05-31 | 2017-05-31 | 14 |  |  |  |
